# RESTAURATION DU CHATEAU D’ANDEVILLE

Schedule from GanttProject, 2017-08-28 to 2018-08-03.
cabinet d'architecte
Holidays every year on 01-01, 05-01, 05-08, 07-14, 08-15, 11-01, 11-11, 12-25

## Calendars

- Project calendar: Mon-Fri working; Sat-Sun off.

## Resources

| Resource |
| --- |
| Architecte |
| Entreprise de maçonnerie |
| Toutes les entreprises |
| Entreprise de charpente |
| Entreprise de couverture |
| Enteprise menuiseries extérieures |
| Entreprise de plâtrerie |
| Entreprise de peinture |
| Entreprise de carrelage |
| Entreprise d'électricité |
| Entreprise de plomberie |
| Equipe maçonnerie rénovation |
| Equipe maçonnerie extension |

## Schedule

| ID | Task | Duration | Start | Finish | Predecessors | Resources |
| --- | --- | --- | --- | --- | --- | --- |
| 1 | signature des O.S | 5d | 2017-08-28 | 2017-09-01 |  | Architecte |
| 2 | préparation de chantier | 20d | 2017-09-04 | 2017-09-29 | 1 | Toutes les entreprises |
| 3 | lot 01 démolition-VRD-GO-EV | 60d | 2017-10-02 | 2017-12-26 | 2 | Entreprise de maçonnerie |
| 4 | lot 02 charpente | 40d | 2017-10-30 | 2017-12-26 | 3SS+20d | Entreprise de charpente |
| 5 | lot 03 couverture | 40d | 2017-11-28 | 2018-01-24 | 4SS+20d | Entreprise de couverture |
| 6 | lot 04 étanchéité | 20d | 2017-12-12 | 2018-01-10 | 3SS+50d |  |
| 7 | lot 05 menuiseries extérieures | 40d | 2017-12-12 | 2018-02-07 | 5SS+10d | Enteprise menuiseries extérieures |
| 8 | lot 06 platrerie, menuiseries intérieures | 80d | 2018-01-11 | 2018-05-03 | 7SS+20d | Entreprise de plâtrerie |
| 9 | lot 07 peinture | 40d | 2018-05-04 | 2018-06-29 | 8 | Entreprise de peinture |
| 10 | lot 08 carrelage | 20d | 2018-05-04 | 2018-06-01 | 8 | Entreprise de carrelage |
| 11 | lot 09 électricité | 210d | 2017-10-02 | 2018-07-27 | 2 |  |
| 12 | lot 10 plomberie, chauffage | 210d | 2017-10-02 | 2018-07-27 | 2 | Entreprise de plomberie |
| 13 | lot 01 finition, vrd | 20d | 2018-04-04 | 2018-05-02 |  | Entreprise de maçonnerie |
| 14 | levées de réserve | 5d | 2018-07-23 | 2018-07-27 | 11FS-5d, 12FS-5d | Toutes les entreprises |
| 15 | réception de travaux | 5d | 2018-07-30 | 2018-08-03 | 11, 12 |  |
